# LRAUVImager_EngineeringSchedule

Schedule from MS Project, 2014-01-27 to 2014-06-19.
Hewlett-Packard Company

## Calendars

- Standard: Mon-Fri 08:00-12:00, 13:00-17:00; Sat-Sun off. Exceptions (off unless hours are given): 2014-04-05 08:00-12:00, 13:00-17:00.

## Resources

| Resource |
| --- |
| Mark Chaffey |
| Rich Henthorn |
| François Cazenave |
| Kim Reisenbichler |

## Schedule

| ID | Task | Type | Duration | Start | Finish | Predecessors | Total slack | Free slack | Constraint | Resources | Work |
| --- | --- | --- | --- | --- | --- | --- | --- | --- | --- | --- | --- |
| 1 | Capture draft of design requirements |  | 39d | 2014-01-27 | 2014-03-20 |  | 155d | 19d | start no earlier than 2014-01-27 | Mark Chaffey [60%] | 82.22h |
| 2 | Research camera and recorder options |  | 10d | 2014-03-21 | 2014-04-03 |  | 136d | 0d | start no earlier than 2014-03-16 | Mark Chaffey [60%] | 48h |
| 3 | Select top three camera and recorder options |  | 2d | 2014-04-04 | 2014-04-05 | 2 | 136d | 0d |  | Mark Chaffey [60%] | 9.6h |
| 4 | Draft optical design specification and lens selection |  | 5d | 2014-04-07 | 2014-04-11 | 3 | 136d | 0d |  | Mark Chaffey [60%] | 24h |
| 5 | Identify optical consulant |  | 2d | 2014-04-14 | 2014-04-15 | 4 | 136d | 0d |  | Mark Chaffey [60%] | 9.6h |
| 6 | Concept design review | milestone | 0d | 2014-04-15 | 2014-04-15 | 3, 5, 1 | 136d | 0d |  | Mark Chaffey [60%]; Rich Henthorn [60%]; Kim Reisenbichler; François Cazenave [60%] |  |
| 7 | Design and construct camera test rig |  | 5d | 2014-04-16 | 2014-04-22 | 6 | 136d | 0d |  | Mark Chaffey [60%] | 24h |
| 8 | Test three camera options |  | 10d | 2014-04-23 | 2014-05-06 | 7 | 136d | 0d |  | Mark Chaffey [60%] | 48h |
| 9 | Evaluate camera test results |  | 5d | 2014-05-07 | 2014-05-13 | 8 | 136d | 0d |  | Mark Chaffey [60%] | 24h |
| 10 | Select optimal camera system |  | 2d | 2014-05-14 | 2014-05-15 | 9 | 136d | 0d |  | Mark Chaffey [60%] | 9.6h |
| 11 | Complete system design |  | 5d | 2014-05-16 | 2014-05-22 | 10 | 136d | 0d |  | Mark Chaffey [60%] | 24h |
| 12 | Preliminary design review | milestone | 0d | 2014-05-22 | 2014-05-22 | 11 | 136d | 0d |  | Mark Chaffey [60%]; Rich Henthorn [60%] |  |
| 13 | Final Optical design |  | 10d | 2014-05-23 | 2014-06-05 | 12 | 136d | 10d |  | Mark Chaffey [60%] | 16h |
| 14 | Housing mechanical design |  | 10d | 2014-06-06 | 2014-06-19 | 13FF | 126d |  | start no earlier than 2014-06-06 | Mark Chaffey [60%] | 8h |
